# SMART-Project-98

Schedule from MS Project, 2001-01-03 to 2001-05-03.
Cable & Wireless

## Calendars

- Standard: Mon-Fri 08:00-12:00, 13:00-17:00; Sat-Sun off. Exceptions (off unless hours are given): 2001-04-01 08:00-12:00, 13:00-17:00, 2001-04-15 08:00-12:00, 13:00-17:00, 2001-04-22 08:00-12:00, 13:00-17:00.

## Schedule

| ID | WBS | Task | Type | Duration | Start | Finish | Predecessors | Total slack | Free slack | Constraint |
| --- | --- | --- | --- | --- | --- | --- | --- | --- | --- | --- |
| 1 | 1 | **SMART Project** |  | 90d | 2001-01-03 | 2001-05-03 |  | 0d |  |  |
| 2 | 1.1 | Project Brainstorming |  | 8d | 2001-01-03 | 2001-01-12 |  | 82d |  | finish no earlier than 2001-01-12 |
| 3 | 1.2 | Develop Project Proposal |  | 13d | 2001-01-04 | 2001-01-22 |  | 17d | 0d | finish no earlier than 2001-01-22 |
| 4 | 1.3 | Proposal Brief/Presentation | milestone | 1d | 2001-01-23 | 2001-01-23 | 3 | 17d | 0d |  |
| 5 | 1.4 | Install Oracle on PM02RG |  | 5d | 2001-01-16 | 2001-01-22 |  | 76d |  | start no earlier than 2001-01-16 |
| 6 | 1.5 | Gather System Requirements |  | 5d | 2001-01-24 | 2001-01-30 | 4 | 17d | 0d | finish no earlier than 2001-01-29 |
| 7 | 1.6 | Publish SRD | milestone | 1d | 2001-01-31 | 2001-01-31 | 6 | 17d | 4d | start no earlier than 2001-01-30 |
| 8 | 1.7 | Develop Project Web Page |  | 5d | 2001-01-30 | 2001-02-05 |  | 65d | 5d | start no earlier than 2001-01-30 |
| 9 | 1.8 | Deploy Project Web Page | milestone | 1d | 2001-02-06 | 2001-02-06 | 8 | 65d |  | start no earlier than 2001-02-06 |
| 10 | 1.9 | Perform Analysis |  | 5d | 2001-02-07 | 2001-02-13 | 7 | 16d | 0d | finish no earlier than 2001-02-13 |
| 11 | 1.10 | Preliminary System Design |  | 9d | 2001-02-14 | 2001-02-26 | 10 | 13d | 0d | finish no earlier than 2001-02-26 |
| 12 | 1.11 | Publish Draft SDD | milestone | 0d | 2001-02-27 | 2001-02-27 | 11 | 16d | 0d | start no earlier than 2001-02-27 |
| 13 | 1.12 | Coding |  | 17d | 2001-02-27 | 2001-03-21 | 12 | 16d | 0d | start no earlier than 2001-02-27 |
| 14 | 1.13 | Update Design |  | 2d | 2001-03-22 | 2001-03-23 | 13 | 16d | 1d | start no earlier than 2001-03-22 |
| 15 | 1.14 | Update SDD |  | 6d | 2001-03-27 | 2001-04-02 | 14 | 13d | 0d | start no earlier than 2001-03-27 |
| 16 | 1.15 | Publish Final SDD | milestone | 0d | 2001-04-03 | 2001-04-03 | 15 | 15d | 0d | start no earlier than 2001-04-03 |
| 17 | 1.16 | Coding |  | 10d | 2001-04-03 | 2001-04-15 | 16 | 15d |  | finish no earlier than 2001-04-09 |
| 18 | 1.18 | Development Test Plan |  | 18d | 2001-03-27 | 2001-04-17 |  | 13d | 0d | finish no earlier than 2001-04-17 |
| 19 | 1.19 | Publish STP | milestone | 0d | 2001-04-17 | 2001-04-17 | 18 | 13d |  | start no earlier than 2001-04-03 |
| 20 | 1.20 | Test |  | 2d | 2001-04-19 | 2001-04-20 |  | 9d | 0d | start no earlier than 2001-04-19 |
| 21 | 1.21 | Publish Test Report | milestone | 1d | 2001-04-22 | 2001-04-22 | 20 | 9d |  | start no earlier than 2001-04-22 |
| 22 | 1.22 | Develop Project Report |  | 6d | 2001-04-16 | 2001-04-22 |  | 1d | 0d | finish no earlier than 2001-04-22 |
| 23 | 1.23 | Deliver Project to Advisor | milestone | 0d | 2001-04-23 | 2001-04-23 | 22 | 1d | 0d | start no earlier than 2001-04-23 |
| 24 | 1.23 | Update Documents as Necessary |  | 4d | 2001-04-23 | 2001-04-26 | 23 | 1d | 0d |  |
| 25 | 1.24 | Deliver Project to Committee Members | milestone | 0d | 2001-04-26 | 2001-04-26 | 24 | 1d | 0d |  |
| 26 | 1.25 | Final Presentation Preparation |  | 3d | 2001-04-27 | 2001-05-01 | 25 | 1d |  |  |
| 27 | 1.24 | Final Report Brief/Presentation | milestone | 1d | 2001-05-03 | 2001-05-03 | 26 | 0d |  | start no earlier than 2001-05-03 |
